# PLAN DE TRABAJO2

Schedule from MS Project, 2018-01-01 to 2018-03-15.

## Calendars

- Estándar: Mon-Fri 09:00-13:00, 15:00-19:00; Sat-Sun off.

## Schedule

| ID | WBS | Task | Type | Duration | Start | Finish | Predecessors | Total slack |
| --- | --- | --- | --- | --- | --- | --- | --- | --- |
| 1 | 1 | **FASE 1: TRABAJOS PREVIOS** |  | 36d | 2018-01-01 | 2018-02-19 |  | 0d |
| 2 | 1.1 | Acondicionamiento de pista de acceso |  | 5d | 2018-01-01 | 2018-01-05 |  | 0d |
| 3 | 1.2 | Desbroce |  | 5d | 2018-01-08 | 2018-01-12 | 2 | 0d |
| 4 | 1.3 | Cierre puntual de rellenos |  | 2d | 2018-01-11 | 2018-01-12 | 3FS-2d | 0d |
| 5 | 1.4 | Construcción de cuneta perimetral oeste |  | 9d | 2018-01-15 | 2018-01-25 | 4 | 17d |
| 6 | 1.5 | Construcción de cuneta perimetral este |  | 9d | 2018-01-15 | 2018-01-25 | 4 | 0d |
| 7 | 1.6 | Ejecución de drenes de fondo longitudinales |  | 4d | 2018-01-24 | 2018-01-29 | 6FS-2d | 0d |
| 8 | 1.7 | Ejecución de drenes de fondo transversales |  | 5d | 2018-01-30 | 2018-02-05 | 7 | 0d |
| 9 | 1.8 | Arquetas de registro |  | 3d | 2018-02-06 | 2018-02-08 | 8 | 7d |
| 10 | 1.9 | Balsas de decantación |  | 7d | 2018-02-06 | 2018-02-14 | 8 | 0d |
| 11 | 1.10 | Construcción de vial interior |  | 5d | 2018-02-13 | 2018-02-19 | 10FS-2d | 0d |
| 12 | 2 | Inicio de vertido | milestone | 0d | 2018-02-19 | 2018-02-19 | 1 | 0d |
| 13 | 3 | Finalización de vertidos | milestone | 0d | 2018-02-19 | 2018-02-19 | 12 | 0d |
| 14 | 4 | **FASE 3: DESMANTELAMIENTO DE INSTALACIONES** |  | 18d | 2018-02-20 | 2018-03-15 | 13 | 0d |
| 15 | 4.1 | Cuneta en tierra en bermas |  | 5d | 2018-02-20 | 2018-02-26 |  | 0d |
| 16 | 4.2 | Hidrosiembra |  | 6d | 2018-02-27 | 2018-03-06 | 15 | 0d |
| 17 | 4.3 | Demolición de balsa de decantación |  | 2d | 2018-03-07 | 2018-03-08 | 16 | 0d |
| 18 | 4.4 | Desmontaje de caseta de control de acceso |  | 3d | 2018-03-09 | 2018-03-13 | 17 | 0d |
| 19 | 4.5 | Desmontaje de cierre de rellenos |  | 2d | 2018-03-14 | 2018-03-15 | 18 | 0d |
| 20 | 5 | GESTIÓN DE RESIDUOS |  | 54d | 2018-01-01 | 2018-03-15 |  | 0d |
| 21 | 6 | CONTROL DE CALIDAD |  | 54d | 2018-01-01 | 2018-03-15 |  | 0d |
| 22 | 7 | SEGURIDAD Y SALUD |  | 54d | 2018-01-01 | 2018-03-15 |  | 0d |
